# Έργο_Αναφωνητρια

Schedule from MS Project, 2018-06-01 to 2020-04-09.

## Calendars

- Τυπικό: Mon-Fri 08:00-12:00, 13:00-17:00; Sat-Sun off.

## Resources

| Resource |
| --- |
| Μελέτη |

## Schedule

| ID | WBS | Task | Duration | Start | Finish | Predecessors | Total slack | Free slack |
| --- | --- | --- | --- | --- | --- | --- | --- | --- |
| 1 | 1 | **1) Έρευνα-Τεκμηρίωση-Πληροφόρηση** | 95d | 2018-06-01 | 2018-10-11 |  | 0d |  |
| 2 | 1.1 | 1.1 Μελέτη-Έρευνα | 10d | 2018-06-01 | 2018-06-14 |  | 0d |  |
| 3 | 1.2 | 1.2 Ανασκαφικές εργασίες | 30d | 2018-06-15 | 2018-07-26 | 2 | 0d |  |
| 4 | 1.3 | 1.3 Σχεδιάσεις-Αποτυπώσεις | 20d | 2018-07-27 | 2018-08-23 | 3 | 0d |  |
| 5 | 1.4 | 1.4 Φωτογραφική τεκμηρίωση | 5d | 2018-08-24 | 2018-08-30 | 4 | 0d |  |
| 6 | 1.5 | 1.5 Δημοσίευση υλικού | 10d | 2018-08-31 | 2018-09-13 | 5 | 0d |  |
| 7 | 1.6 | 1.6 Μελέτη αποκατάστασης | 20d | 2018-09-14 | 2018-10-11 | 6 | 0d |  |
| 8 | 2 | **2) Εργασίες πεδίου** | 390d | 2018-10-12 | 2020-04-09 |  | 0d |  |
| 9 | 2.1 | 2.1 Αποψιλώσεις-καθαρισμοί | 5d | 2018-10-12 | 2018-10-18 | 7 | 325d | 0d |
| 10 | 2.2 | 2.2 Φυτεύσεις | 10d | 2020-03-27 | 2020-04-09 | 37 | 0d |  |
| 11 | 3 | **3) Περιφράξεις** | 10d | 2020-03-27 | 2020-04-09 |  | 0d |  |
| 12 | 3.1 | 3.1 Ελαφρές περιφράξεις | 5d | 2020-03-27 | 2020-04-02 | 37 | 0d |  |
| 13 | 3.2 | 3.2 Θύρες εισόδου | 5d | 2020-04-03 | 2020-04-09 | 12 | 0d |  |
| 14 | 4 | **4) Εγκαταστάσεις εξυπηρέτησης κοινού** | 385d | 2018-10-12 | 2020-04-02 |  | 5d |  |
| 15 | 4.1 | **4.1 Κτήρια εξυπηρέτησης κοινού** | 95d | 2018-10-12 | 2019-02-21 |  | 290d |  |
| 16 | 4.1.1 | 4.1.1 Εκσκαφή | 5d | 2018-10-12 | 2018-10-18 | 7 | 290d | 0d |
| 17 | 4.1.2 | 4.1.2 Σκυροδέτηση | 15d | 2018-10-19 | 2018-11-08 | 16 | 290d | 0d |
| 18 | 4.1.3 | 4.1.3 Τοιχοποιίες | 20d | 2018-11-16 | 2018-12-13 | 17FS+5d | 290d | 0d |
| 19 | 4.1.4 | 4.1.4 Υδραυλικές και ηλεκτρ/μηχ. Εγκαταστάσεις | 20d | 2018-12-14 | 2019-01-10 | 18 | 290d | 0d |
| 20 | 4.1.5 | 4.1.5 Επιχρίσματα | 10d | 2019-01-11 | 2019-01-24 | 19 | 290d | 0d |
| 21 | 4.1.6 | 4.1.6 Κουφώματα-Ανοίγματα | 5d | 2019-01-25 | 2019-01-31 | 20 | 310d |  |
| 22 | 4.1.7 | 4.1.7 Δάπεδα | 10d | 2019-01-25 | 2019-02-07 | 20 | 305d |  |
| 23 | 4.1.8 | 4.1.8 Στέγη | 15d | 2019-01-25 | 2019-02-14 | 20 | 295d | 0d |
| 24 | 4.1.9 | 4.1.9 Ελαιοχρωματισμοί | 5d | 2019-02-15 | 2019-02-21 | 23 | 295d |  |

| ID | WBS | Task | Duration | Start | Finish | Predecessors | Total slack | Free slack |
| --- | --- | --- | --- | --- | --- | --- | --- | --- |
| 25 | 4.2 | **4.2 Πλατώματα θέασης-Διαδρομές επισκεπτών** | 25d | 2019-01-25 | 2019-02-28 |  | 290d |  |
| 26 | 4.2.1 | 4.2.1 Διαμόρφωση εδάφους | 10d | 2019-01-25 | 2019-02-07 | 20 | 290d | 0d |
| 27 | 4.2.2 | 4.2.2 Πλακόστρωση | 10d | 2019-02-08 | 2019-02-21 | 26 | 290d | 0d |
| 28 | 4.2.3 | 4.2.3 Τοποθέτηση σκιάστρων | 5d | 2019-02-22 | 2019-02-28 | 27 | 290d |  |
| 29 | 4.3 | **4.3 Χώροι στάθμευσης** | 10d | 2018-10-19 | 2018-11-01 |  | 375d |  |
| 30 | 4.3.1 | 4.3.1 Διαμόρφωση εδάφους | 5d | 2018-10-19 | 2018-10-25 | 9 | 375d | 0d |
| 31 | 4.3.2 | 4.3.2 Ασφαλτόστρωση | 5d | 2018-10-26 | 2018-11-01 | 30 | 375d |  |
| 32 | 4.4 | **4.4 Δίκτυα** | 60d | 2018-10-19 | 2019-01-10 |  | 325d |  |
| 33 | 4.4.1 | 4.4.1 Δίκτυο φωτισμού | 20d | 2018-10-19 | 2018-11-15 | 9 | 325d | 0d |
| 34 | 4.4.2 | 4.4.2 Δίκτυο ύδρευσης-άδρευσης | 20d | 2018-11-16 | 2018-12-13 | 33 | 325d | 0d |
| 35 | 4.4.3 | 4.4.3 Δίκτυο αποχέτευσης-ομβρίων | 20d | 2018-12-14 | 2019-01-10 | 34 | 325d |  |
| 36 | 4.5 | 4.5 Πινακίδες πληροφόρησης κοινού | 5d | 2020-03-27 | 2020-04-02 | 37 | 5d |  |
| 37 | 5 | **5) Προστασία & Ανάδειξη μνημείων** | 380d? | 2018-10-12 | 2020-03-26 |  | 0d |  |
| 38 | 5.1 | **5.1 Αναστηλωτικές εργασίες** | 190d? | 2019-01-04 | 2019-09-26 |  | 0d |  |
| 39 | 5.1.1 | 5.1.1 Αποκατάσταση λιθοδομών | 100d? | 2019-01-04 | 2019-05-23 | 52, 54 | 0d |  |
| 40 | 5.1.2 | 5.1.2 Αποκατάσταση δαπέδων | 20d? | 2019-08-30 | 2019-09-26 | 47 | 0d |  |
| 41 | 5.1.3 | 5.1.3 Αποκατάσταση επιχρισμάτων | 20d? | 2019-08-16 | 2019-09-12 | 43, 44 | 10d |  |
| 42 | 5.2 | **5.2 Μικροστερεώσεις** | 60d | 2019-05-24 | 2019-08-15 |  | 10d |  |
| 43 | 5.2.1 | 5.2.1 Αρμολογήματα | 60d | 2019-05-24 | 2019-08-15 | 39 | 10d | 0d |
| 44 | 5.2.2 | 5.2.2 Επισκευή ρωγμών | 20d | 2019-05-24 | 2019-06-20 | 39 | 50d | 40d |
| 45 | 5.3 | **5.3 Συντήρηση ξύλινων στοιχείων** | 50d | 2019-06-21 | 2019-08-29 |  | 0d |  |
| 46 | 5.3.1 | 5.3.1 Αποξήλωση φθαρμένης ξυλείας | 20d | 2019-06-21 | 2019-07-18 | 53 | 0d |  |
| 47 | 5.3.2 | 5.3.2 Αποκατάσταση-επισκευή ξύλινων στοιχείων | 30d | 2019-07-19 | 2019-08-29 | 46 | 0d |  |
| 48 | 5.4 | **5.4 Επισκευή στεγών** | 50d | 2019-07-19 | 2019-09-26 |  | 130d |  |
| 49 | 5.4.1 | 5.4.1 Συντήρηση ξύλινων στοιχείων | 20d | 2019-07-19 | 2019-08-15 | 46 | 160d |  |
| 50 | 5.4.2 | 5.4.2 Ανακεράμωση | 20d | 2019-08-30 | 2019-09-26 | 47 | 130d |  |

| ID | WBS | Task | Duration | Start | Finish | Predecessors | Total slack |
| --- | --- | --- | --- | --- | --- | --- | --- |
| 51 | 5.5 | **5.5 Καθαιρέσεις** | 180d | 2018-10-12 | 2019-06-20 |  | 0d |
| 52 | 5.5.1 | 5.5.1 Καθαίρεση αρμολογημάτων | 40d | 2018-10-12 | 2018-12-06 | 7 | 20d |
| 53 | 5.5.2 | 5.5.2 Καθαίρεση κεραμιδιών | 20d | 2019-05-24 | 2019-06-20 | 39 | 0d |
| 54 | 5.5.3 | 5.5.3 Καθαίρεση επιχρισμάτων | 60d | 2018-10-12 | 2019-01-03 | 7 | 0d |
| 55 | 5.6 | **5.6 Συντηρήση επιφανειών-διάκοσμου** | 130d? | 2019-09-27 | 2020-03-26 |  | 0d |
| 56 | 5.6.1 | 5.6.1 Συντήρηση τοιχογραφιών | 120d | 2019-09-27 | 2020-03-12 | 38 | 0d |
| 57 | 5.6.2 | 5.6.2 Συντήρηση ξύλινου τέμπλου | 60d | 2019-09-27 | 2019-12-19 | 38 | 60d |
| 58 | 5.6.3 | 5.6.3 Συντήρηση ψηφιδωτου | 90d | 2019-09-27 | 2020-01-30 | 38 | 30d |
| 59 | 5.6.4 | 5.6.4 Εργασίες ελαιοχρωματισμών | 10d? | 2020-03-13 | 2020-03-26 | 56, 57, 58 | 0d |
